# Proyect1

Schedule from MS Project, 2009-06-01 to 2010-03-04, status date 2009-01-22.
.

## Calendars

- Estándar: Mon-Fri 09:00-13:00, 15:00-19:00; Sat-Sun off.

## Schedule

| ID | WBS | Task | Duration | Start | Finish | Predecessors | Total slack | Free slack |
| --- | --- | --- | --- | --- | --- | --- | --- | --- |
| 1 | 1 | **PROYECTO** | 199d | 2009-06-01 | 2010-03-04 |  | 0d |  |
| 2 | 1.1 | Cierros provisorios | 10d | 2009-06-01 | 2009-06-12 |  | 0d |  |
| 3 | 1.2 | Instalacion de faenas | 7d | 2009-06-15 | 2009-06-23 | 2 | 0d |  |
| 4 | 1.3 | Suministro y colocacion de Letreros Indicativos | 2d | 2009-06-15 | 2009-06-16 | 3SS | 187d |  |
| 5 | 1.4 | Demolision y retiro de soleras | 7d | 2009-06-15 | 2009-06-23 | 3SS | 0d |  |
| 6 | 1.5 | Demolision y retiro de solerillas | 4d | 2009-06-24 | 2009-06-29 | 3 | 178d |  |
| 7 | 1.6 | Demolicion aceras | 20d | 2009-06-15 | 2009-07-10 | 5SS | 0d |  |
| 8 | 1.7 | Retiro de exedentes | 7d | 2009-07-13 | 2009-07-21 | 7 | 162d |  |
| 9 | 1.8 | Demolicion y retiro de calzadas | 20d | 2009-07-13 | 2009-08-07 | 7 | 0d |  |
| 10 | 1.9 | Demolision y retiro Sumideros | 8d | 2009-07-15 | 2009-07-24 | 9SS+2d | 159d |  |
| 11 | 1.10 | Retiro barandas peatonales | 6d | 2009-07-15 | 2009-07-22 | 9SS+2d | 161d |  |
| 12 | 1.11 | Excavacion y transporte a botadero | 10d | 2009-08-10 | 2009-08-21 | 9 | 34d | 0d |
| 13 | 1.12 | Excavaciones poliducto y atravieso calles | 10d | 2009-08-10 | 2009-08-21 | 9 | 0d |  |
| 14 | 1.13 | Obras poliducto Baja Tension | 20d | 2009-08-24 | 2009-09-18 | 13 | 92d | 8d |
| 15 | 1.14 | Obras poliducto Alta Tension | 20d | 2009-08-24 | 2009-09-18 | 13 | 92d | 8d |
| 16 | 1.15 | Obras Poliducto C.D | 28d | 2009-08-24 | 2009-09-30 | 13 | 0d |  |
| 17 | 1.16 | Empalmes alumbrado público | 10d | 2009-10-01 | 2009-10-14 | 14, 15, 16 | 84d | 0d |
| 18 | 1.17 | Instalacion de cables xcs | 10d | 2009-10-15 | 2009-10-28 | 17 | 84d | 0d |
| 19 | 1.18 | Modificacion cámaras de alcantarillado | 8d | 2009-10-01 | 2009-10-12 | 12SS+3d, 16 | 0d |  |
| 20 | 1.19 | Modificacion cámaras agua potable | 7d | 2009-10-01 | 2009-10-09 | 12SS+3d, 16 | 1d |  |
| 21 | 1.20 | Renovacion de arranques | 10d | 2009-08-24 | 2009-09-04 | 12 | 129d |  |
| 22 | 1.21 | Modificacion cámaras de gas | 7d | 2009-10-01 | 2009-10-09 | 12SS+3d, 16 | 1d |  |
| 23 | 1.22 | Preparacion subrrasante | 10d | 2009-10-13 | 2009-10-26 | 12FS+2d, 19, 20, 22 | 0d |  |
| 24 | 1.23 | Rellenos compactados | 10d | 2009-10-27 | 2009-11-09 | 23 | 0d |  |
| 25 | 1.24 | Base estabilizada CBR>60% Aceras: 0.15 m | 14d | 2009-11-10 | 2009-11-27 | 24 | 1d | 0d |
| 26 | 1.25 | Base estabilizada CBR>60% Aceras reforzadas: 0.10 m | 10d | 2009-11-16 | 2009-11-27 | 24FS+4d | 1d |  |
| 27 | 1.26 | Base estabilizada CBR>60% Estacionamiento: 0.15 m | 7d | 2009-11-10 | 2009-11-18 | 25SS | 76d |  |
| 28 | 1.27 | Base estabilizada CBR> 60% Calzada: 0.15 m | 15d | 2009-11-10 | 2009-11-30 | 24 | 0d |  |
| 29 | 1.28 | Malla ACMA C188 | 15d | 2009-12-01 | 2009-12-21 | 28, 26, 25 | 0d |  |
| 30 | 1.29 | Acera Hormigón estampado e: 8 cm | 10d | 2009-11-30 | 2009-12-11 | 25 | 53d | 0d |
| 31 | 1.30 | Mortero de pega | 7d | 2009-12-01 | 2009-12-09 | 28 | 47d | 0d |
| 32 | 1.31 | Baldosa tipo Budnick | 7d | 2009-12-02 | 2009-12-10 | 31SS+1d | 47d | 0d |
| 33 | 1.32 | Suministro y colocacion solera tipo A | 6d | 2009-12-14 | 2009-12-21 | 30 | 53d |  |
| 34 | 1.33 | Carpeta rodado HCV e: 0.18 m | 21d | 2009-12-22 | 2010-01-19 | 29, 19, 20, 22 | 0d |  |
| 35 | 1.34 | Cubierta hormigón estampado | 21d | 2009-12-23 | 2010-01-20 | 34SS+1d | 0d |  |
| 36 | 1.35 | Canaleta AALL de Hormigón con rejilla | 20d | 2009-11-10 | 2009-12-07 | 28SS | 63d | 0d |
| 37 | 1.36 | Sumidero tipo serviu | 15d | 2009-11-10 | 2009-11-30 | 36SS | 68d | 0d |
| 38 | 1.37 | Dado de refuerzo | 10d | 2009-11-10 | 2009-11-23 | 37SS | 73d |  |
| 39 | 1.38 | Cubo H.A Busto Pedro A.C. | 6d | 2009-12-02 | 2009-12-09 | 32SS | 61d |  |
| 40 | 1.39 | Instalacion y colocacion de luminarias | 7d | 2009-10-29 | 2009-11-06 | 18 | 84d |  |
| 41 | 1.40 | Provicion y colocacion cabinas telefonicas | 6d | 2010-01-21 | 2010-01-28 | 35 | 16d | 0d |
| 42 | 1.41 | Provision y colocacion bolardos | 7d | 2010-01-25 | 2010-02-02 | 41SS+2d | 16d | 0d |
| 43 | 1.42 | Provision y colocacion basureros | 7d | 2010-01-25 | 2010-02-02 | 42SS | 16d | 0d |
| 44 | 1.43 | Jardineras de media y circunferencia completa | 7d | 2010-01-21 | 2010-01-29 | 35 | 24d |  |
| 45 | 1.44 | Provision y colocacion de árboles | 10d | 2010-01-25 | 2010-02-05 | 43SS | 16d | 0d |
| 46 | 1.45 | Provision y colocacion de arbustos , especies florales | 5d | 2010-01-25 | 2010-01-29 | 45SS | 24d |  |
| 47 | 1.46 | Provision y colocacion de rejilla y tutor metalico | 3d | 2010-02-08 | 2010-02-10 | 45 | 16d |  |
| 48 | 1.47 | Ejecucion jardinera cuadrada con asientos triple | 20d | 2009-12-02 | 2009-12-29 | 32SS | 47d | 0d |
| 49 | 1.48 | Ejecucion jardinera curva con asiento doble | 10d | 2009-12-02 | 2009-12-15 | 48SS | 57d |  |
| 50 | 1.49 | Escaños con jardinera incorporada | 25d | 2010-01-21 | 2010-02-24 | 35 | 6d |  |
| 51 | 1.50 | Bebederos de agua | 2d | 2009-12-11 | 2009-12-14 | 32 | 58d |  |
| 52 | 1.51 | Letreros de transito y señalizacion vial | 4d | 2010-01-21 | 2010-01-26 | 35 | 0d |  |
| 53 | 1.52 | Mantencion e incorporacion de sonido a semaforizacion existente | 10d | 2010-01-21 | 2010-02-03 | 52SS | 0d |  |
| 54 | 1.53 | Demarcaciones | 5d | 2010-02-04 | 2010-02-10 | 53 | 0d |  |
| 55 | 1.54 | Colocacion de tachas | 2d | 2010-02-11 | 2010-02-12 | 54 | 0d |  |
| 56 | 1.55 | Remosion y retiro de escombros | 7d | 2010-02-15 | 2010-02-23 | 55 | 0d |  |
| 57 | 1.56 | Limpieza final | 7d | 2010-02-24 | 2010-03-04 | 56 | 0d |  |
